# ionisation_chamber _production_200405

Schedule from MS Project, 2005-03-01 to 2007-02-23, A marks actual dates.
CERN

## Calendars

- Standard: Mon-Fri 08:00-12:00, 13:00-17:00; Sat-Sun off.

## Schedule

| ID | WBS | Task | Duration | Start | Finish | Predecessors | Complete | Remaining | Baseline start | Baseline finish | Baseline duration | Total slack | Free slack | Constraint |
| --- | --- | --- | --- | --- | --- | --- | --- | --- | --- | --- | --- | --- | --- | --- |
| 1 | 1 | technical specification | 66d? | 2005-03-01 | 2005-05-31 |  |  |  | 2005-03-01 | 2005-05-31 | 66d? | 453d |  | start no earlier than 2005-03-01 |
| 2 | 2 | contract | 66d? | 2005-03-01 | 2005-05-31 |  |  |  | 2005-03-01 | 2005-05-31 | 66d? | 453d |  | start no earlier than 2005-03-01 |
| 3 | 3 | finish design | 23d? | 2005-03-01 | 2005-03-31 |  |  |  | 2005-03-01 | 2005-03-31 | 23d? | 496d |  | start no earlier than 2005-03-01 |
| 4 | 4 | ask for offers for components | 44d? | 2005-03-01 | 2005-04-29 |  |  |  | 2005-03-01 | 2005-03-31 | 23d? | 475d |  | start no earlier than 2005-03-01 |
| 5 | 5 | order components | 15d? | 2005-05-02 | 2005-05-20 |  |  |  | 2005-05-02 | 2005-06-30 | 44d? | 460d |  | start no earlier than 2005-05-02 |
| 6 | 6 | preseries components arive at CERN | 65d? | 2005-05-30 | 2005-08-26 |  |  |  | 2005-06-02 | 2005-06-30 | 21d? | 390d |  | start no earlier than 2005-05-29 |
| 7 | 7 | series components arive at CERN | 161d? | 2005-07-01 | 2006-02-10 |  |  |  | 2005-07-01 | 2005-11-30 | 109d? | 270d |  | start no earlier than 2005-07-01 |
| 9 | 8 | baking, cleaning filling system in IHEP | 3.3mo | 2005-04-01 | 2005-07-01 |  |  |  | 2005-04-01 | 2005-06-15 | 2.7mo | 430d |  | start no earlier than 2005-04-01 |
| 10 | 9 | source test stands in IHEP | 66d? | 2005-04-01 | 2005-07-01 |  |  |  | 2005-04-01 | 2005-06-15 | 54d? | 430d |  | start no earlier than 2005-04-01 |
| 12 | 10 | shipment prep. preseries componets | 1mo | 2005-07-25 | 2005-08-19 |  |  |  | 2005-07-01 | 2005-07-28 | 1mo | 54d | 0d | start no earlier than 2005-07-24 |
| 13 | 11 | shipment preseries comp | 1.85mo | 2005-08-11 | 2005-09-30 | 12FS-7d |  |  | 2005-07-29 | 2005-08-29 | 1.1mo | 54d | 0d |  |
| 14 | 12 | pre-series IC production (IHEP) | 1.5mo | 2005-09-08 | 2005-10-19 | 13SS+1mo, 12SS+1.5mo |  |  | 2005-09-01 | 2005-10-12 | 1.5mo | 54d | 0d | start no earlier than 2005-08-28 |
| 16 | 13 | shipment prep series comp | 5mo | 2005-08-30 | 2006-01-16 |  |  |  | 2005-08-01 | 2005-12-16 | 5mo | 269d | 0d | start no earlier than 2005-08-30 |
| 17 | 14 | shipment series comp | 4mo | 2005-10-25 | 2006-02-13 | 16SS+2mo |  |  | 2005-09-26 | 2006-01-13 | 4mo | 269d |  | start no earlier than 2005-10-09 |
| 18 | 15 | series production IC | 14mo | 2005-11-10 A | 2006-12-11 | 14FS+20d | 1% | 13.9mo | 2005-11-10 | 2006-12-06 | 14mo | 54d |  |  |
| 19 | 16 | Installation | 275d? | 2006-02-06 | 2007-02-23 |  |  |  | 2006-02-06 | 2007-02-23 | 275d? | 0d |  | finish no earlier than 2007-02-23 |
