# production

Schedule from MS Project, 2005-03-01 to 2007-02-23.
CERN

## Calendars

- Standard: Mon-Fri 08:00-12:00, 13:00-17:00; Sat-Sun off.

## Schedule

| ID | WBS | Task | Duration | Start | Finish | Predecessors | Total slack | Free slack | Constraint |
| --- | --- | --- | --- | --- | --- | --- | --- | --- | --- |
| 1 | 1 | technical specification | 66d? | 2005-03-01 | 2005-05-31 |  | 453d |  | start no earlier than 2005-03-01 |
| 2 | 2 | contract | 66d? | 2005-03-01 | 2005-05-31 |  | 453d |  | start no earlier than 2005-03-01 |
| 3 | 3 | finish design | 23d? | 2005-03-01 | 2005-03-31 |  | 496d |  | start no earlier than 2005-03-01 |
| 4 | 4 | ask for offers for components | 23d? | 2005-03-01 | 2005-03-31 |  | 496d |  | start no earlier than 2005-03-01 |
| 5 | 5 | order components | 44d? | 2005-05-02 | 2005-06-30 |  | 431d |  | start no earlier than 2005-05-02 |
| 6 | 6 | preseries components arive at CERN | 21d? | 2005-06-02 | 2005-06-30 |  | 431d |  | finish no earlier than 2005-06-30 |
| 7 | 7 | series components arive at CERN | 109d? | 2005-07-01 | 2005-11-30 |  | 322d |  | start no earlier than 2005-07-01 |
| 9 | 8 | baking, cleaning filling system | 2.7mo | 2005-04-01 | 2005-06-15 |  | 442d |  | start no earlier than 2005-04-01 |
| 10 | 9 | source test stands | 54d? | 2005-04-01 | 2005-06-15 |  | 442d |  | start no earlier than 2005-04-01 |
| 12 | 10 | shipment prep preseries com | 1mo | 2005-07-01 | 2005-07-28 | 6 | 61d | 0d | start no earlier than 2005-07-01 |
| 13 | 11 | shipment preseries comp | 1.1mo | 2005-07-29 | 2005-08-29 | 12 | 61d | 4d |  |
| 14 | 12 | pre-series IC (Russia) | 1.5mo | 2005-09-01 | 2005-10-12 | 13SS+1mo, 12SS+1.5mo | 57d | 0d | start no earlier than 2005-09-01 |
| 16 | 13 | shipment prep series comp | 5mo | 2005-08-01 | 2005-12-16 |  | 290d | 0d | start no earlier than 2005-08-01 |
| 17 | 14 | shipment series comp | 4mo | 2005-09-26 | 2006-01-13 | 16SS+2mo | 290d |  |  |
| 18 | 15 | series production IC | 14mo | 2005-11-10 | 2006-12-06 | 14FS+20d | 57d |  |  |
| 19 | 16 | pre-series SEM | 1.5mo | 2006-01-02 | 2006-02-10 | 12SS+1.5mo | 130d | 0d | start no earlier than 2006-01-01 |
| 20 | 17 | series production SEM | 6mo | 2006-03-13 | 2006-08-25 | 19FS+1mo | 130d |  |  |
| 21 | 18 | Installation | 275d? | 2006-02-06 | 2007-02-23 |  | 0d |  | finish no earlier than 2007-02-23 |
